# 3GPP_Release-2000

Schedule from MS Project, 2000-01-03 to 2008-12-15, A marks actual dates.

## Calendars

- Standard: Mon-Fri 08:00-12:00, 13:00-17:00; Sat-Sun off.

## Resources

| Resource |
| --- |
| NP |
| N1 |
| N2 |
| N3 |
| N4 |
| N5 |
| TP |
| T1 |
| T2 |
| T3 |
| RP |
| R1 |
| R2 |
| R3 |
| R4 |
| SP |
| S1 |
| S2 |
| S3 |
| S4 |
| S5 |
| PCG |
| GP |
| No |
| CN4 |
| ? |
| WG G2 |
| G2 |
| G1 |
| G4 |
| G3 |
| All |
| Generic |
| MLST |
| G5 |
| S3; G2 |
| WG T2 |
| GP;G1 |
| G4;G5 |
| OMA |
| GP-G2 |
| Yes |
| GP; |
| N4; |
| GP; N1 |
| CT5 |
| C5 |
| C1 |
| C4 |
| C3 |
| C6 |
| G1; |
| 4 |
| ct |
| c;s;r |
| CT;RAN;SA |
| G2, |
| G1; G3 |
| CT6 |
| CT1 |
| CT1, CT3, CT4 |
| C1, C3, C4 |
| CP |

## Schedule

| ID | WBS | Task | Duration | Start | Finish | Complete | Remaining | Baseline start | Baseline finish | Baseline duration | Total slack | Constraint | Resources | Work | Actual work | Text9 | Text6 | Text1 | Text4 | Text8 | Text3 | Text5 |
| --- | --- | --- | --- | --- | --- | --- | --- | --- | --- | --- | --- | --- | --- | --- | --- | --- | --- | --- | --- | --- | --- | --- |
| 1 | 1 | VERSION 2007 April 3rd | 1d | 2000-01-03 | 2000-01-03 |  |  | 2000-01-03 | 2000-01-03 | 1d | 2335d |  |  |  |  | 2044 |  |  |  |  |  |  |
| 2 | 2 | "CTRL + a" to display all the 3GPP fields | 1d | 2000-01-03 | 2000-01-03 |  |  | 2000-01-03 | 2000-01-03 | 1d | 2335d |  |  |  |  | 1462 |  |  |  |  |  |  |
| 3 | 3 | Content of Rel-8 (not frozen) | 1d | 2000-01-03 | 2000-01-03 |  |  | 2000-01-03 | 2000-01-03 | 1d | 2335d |  |  |  |  | 2058 |  |  |  |  |  |  |
| 5 | 4 | Release 8 Features | 1d? | 2000-01-03 | 2000-01-03 |  |  | 2000-01-03 | 2000-01-03 | 1d? | 2335d |  | CT;RAN;SA | 8h |  |  | Rel-8 |  |  |  |  |  |
| 6 | 5 | **3G Long Term Evolution** | 320d? | 2006-09-25 A | 2007-12-14 | 21% | 251.28d? | 2006-09-25 | 2007-12-14 | 320d? | 261d |  | RP | 11240h | 2229.6h |  | Rel-8 | LTE | Takehiro Nakamura (NTT DoCoMo) | MCC_RAN |  |  |
| 7 | 5.1 | 3G Long Term Evolution – Physical Layer | 255d? | 2006-09-25 A | 2007-09-14 | 50% | 127.5d? | 2006-09-25 | 2007-09-14 | 255d? | 326d | finish no earlier than 2007-09-14 | R1 | 2040h | 1020h |  | Rel-8 | LTE-Phys | Sadayuki Abeta, NTT DoCoMo | MCC_RAN | 36.2xy |  |
| 8 | 5.2 | 3G Long Term Evolution – Radio Interface Layer 2 and 3 Protocol Aspect | 255d? | 2006-09-25 A | 2007-09-14 | 5% | 242.25d? | 2006-09-25 | 2007-09-14 | 255d? | 326d | finish no earlier than 2007-09-14 | R2 | 2040h | 102h |  | Rel-8 | LTE-L23 | Benoist Sebire, Nokia | MCC_RAN | 36.3xy |  |
| 9 | 5.3 | 3G Long Term Evolution – eUTRAN Interfaces | 255d? | 2006-09-25 A | 2007-09-14 | 5% | 242.25d? | 2006-09-25 | 2007-09-14 | 255d? | 326d | finish no earlier than 2007-09-14 | R3 | 2040h | 102h |  | Rel-8 | LTE-interfaces | Mattias Wahlqvist, Ericsson | MCC_RAN | 36.4xy |  |
| 10 | 5.4 | 3G Long Term Evolution – RF Radio Transmission/Reception, System Performance Requirements and Conformance Testing | 320d? | 2006-09-25 A | 2007-12-14 | 25% | 240d? | 2006-09-25 | 2007-12-14 | 320d? | 261d | finish no earlier than 2007-12-14 | R4 | 2560h | 640h |  | Rel-8 | LTE-RF | Frank Lamprecht, Siemens | MCC_RAN | 36.1xy |  |
| 11 | 6 | **3GPP System Architecture Evolution Specification** | 462d? | 2006-06-08 A | 2008-03-14 | 5% | 437.17d? | 2006-06-08 | 2007-09-14 | 332d? | 196d |  | S2 | 87688h | 4214.41h |  | Rel-8 | SAES | Osok Song (Samsung) | Maurice | 23.228, 23.279 | osok.song@samsung.com |
| 12 | 6.1 | Requirements for evolution of the 3GPP system architecture | 157d? | 2006-06-08 A | 2007-01-12 | 95% | 7.85d? | 2006-06-08 | 2007-01-12 | 157d? | 501d | finish no earlier than 2007-01-12 | S1 | 1256h | 1193.2h |  | Rel-8 | AIPN-SAE | Michael Kurz (T-Mobile International) | Michael | 22.278 | michael.kurz@t-mobile.at |
| 13 | 6.2 | **SA aspects of System Architecture Evolution** | 249d? | 2007-01-02 A | 2007-12-14 | 13% | 217.54d? |  |  |  | 261d |  |  | 17928h | 2264.95h |  |  |  |  |  |  |  |
| 14 | 6.2.1 | High level functions (common high level functions for all accesses) | 249d? | 2007-01-02 A | 2007-12-14 | 26% | 185d? |  |  |  | 261d | finish no earlier than 2007-12-14 | S2 | 1992h | 512h |  | Rel-8 |  |  |  |  |  |
| 15 | 6.2.2 | Functions and procedures for SAE to support LTE access | 249d? | 2007-01-02 A | 2007-12-14 | 26% | 184.26d? |  |  |  | 261d | start no earlier than 2007-01-02 | S2 | 1992h | 517.92h |  | Rel-8 |  |  |  |  |  |
| 16 | 6.2.3 | Functions and procedures for SAE to support 3GPP accesses (LTE <-> 2G/3G) | 249d? | 2007-01-02 A | 2007-12-14 | 26% | 184.26d? |  |  |  | 261d | start no earlier than 2007-01-02 | S2 | 1992h | 517.92h |  | Rel-8 |  |  |  |  |  |
| 17 | 6.2.4 | Functions and procedures for SAE to support non-3GPP accesses | 249d? | 2007-01-02 A | 2007-12-14 | 26% | 184.26d? |  |  |  | 261d | start no earlier than 2007-01-02 | S2 | 1992h | 517.92h |  | Rel-8 |  |  |  |  |  |
| 18 | 6.2.5 | Functions and procedures for SAE to support LTE MBMS | 249d? | 2007-01-02 | 2007-12-14 |  |  |  |  |  | 261d | start no earlier than 2007-01-02 | S2 | 1992h |  |  | Rel-8 |  |  |  |  |  |
| 19 | 6.2.6 | Functions and procedures for SAE to support LCS | 249d? | 2007-01-02 | 2007-12-14 |  |  |  |  |  | 261d | start no earlier than 2007-01-02 | S2 | 1992h |  |  | Rel-8 |  |  |  |  |  |
| 20 | 6.2.7 | Single Radio Voice Call Continuity | 249d? | 2007-01-02 A | 2007-12-14 | 5% | 236.55d? |  |  |  | 261d | start no earlier than 2007-01-02 | S2 | 1992h | 99.6h |  | Rel-8 |  |  |  |  |  |
| 21 | 6.2.8 | SAE impacts on IMS | 249d? | 2007-01-02 A | 2007-12-14 | 5% | 236.55d? |  |  |  | 261d | start no earlier than 2007-01-02 | S2 | 1992h | 99.6h |  | Rel-8 |  |  |  |  |  |
| 22 | 6.2.9 | SAE aspects of Emergency Calls | 249d? | 2007-01-02 | 2007-12-14 |  |  |  |  |  | 261d | start no earlier than 2007-01-02 | S2 | 1992h |  |  | Rel-8 |  |  |  |  |  |
| 23 | 6.3 | **CT aspects of System Architecture Evolution** | 290d? | 2007-02-05 | 2008-03-14 |  |  | 2007-02-05 | 2008-03-14 | 290d? | 196d |  | CP | 59320h |  |  | Rel-8 | SAES-St3 | Hannu Hietalahti, Nokia | Andrijana, Seung Don, Kimmo | 24.8yz, 29.8ab, 29.8cd | hannu.hietalahti@nokia.com |
| 24 | 6.3.1 | **CT1 aspects of SAES** | 290d? | 2007-02-05 | 2008-03-14 |  |  | 2007-02-05 | 2008-03-14 | 290d? | 196d |  | C1 | 16240h |  |  | Rel-8 | SAES-St3 |  |  |  |  |
| 25 | 6.3.1.1 | Network selection procedures | 290d? | 2007-02-05 | 2008-03-14 |  |  | 2007-02-05 | 2008-03-14 | 290d? | 196d | start no earlier than 2007-02-05 | C1 | 2320h |  |  | Rel-8 | SAES-St3-netsel |  |  |  |  |
| 26 | 6.3.1.2 | UE NAS mobility procedures in idle and active mode | 290d? | 2007-02-05 | 2008-03-14 |  |  | 2007-02-05 | 2008-03-14 | 290d? | 196d | start no earlier than 2007-02-05 | C1 | 2320h |  |  | Rel-8 | SAES-St3-NASmob |  |  |  |  |
| 27 | 6.3.1.3 | Bearer control and QoS aspects | 290d? | 2007-02-05 | 2008-03-14 |  |  | 2007-02-05 | 2008-03-14 | 290d? | 196d | start no earlier than 2007-02-05 | C1 | 2320h |  |  | Rel-8 | SAES-St3-BCQOS |  |  |  |  |
| 28 | 6.3.1.4 | CT1 SAE impact on existing capabilities | 290d? | 2007-02-05 | 2008-03-14 |  |  | 2007-02-05 | 2008-03-14 | 290d? | 196d | start no earlier than 2007-02-05 | C1 | 2320h |  |  | Rel-8 | SAES-St3-CT1imp |  |  |  |  |
| 29 | 6.3.1.5 | Interoperability | 290d? | 2007-02-05 | 2008-03-14 |  |  | 2007-02-05 | 2008-03-14 | 290d? | 196d | start no earlier than 2007-02-05 | C1 | 2320h |  |  | Rel-8 | SAES-St3-interop |  |  |  |  |
| 30 | 6.3.1.6 | CT1 security aspects | 290d? | 2007-02-05 | 2008-03-14 |  |  | 2007-02-05 | 2008-03-14 | 290d? | 196d | start no earlier than 2007-02-05 | C1 | 2320h |  |  | Rel-8 | SAES-St3-CT1sec |  |  |  |  |

Notes:
- 11: S2#52: Specification phase created. New WID approved SA#32
- 12: Moved to SA2 at SA#32
- 13: S2 internal target is September 2007
- 19: SA2 need RAN outputs (RAN dependencies)
- 23: CT wide WID approved ib CT#34

| ID | WBS | Task | Duration | Start | Finish | Complete | Remaining | Baseline start | Baseline finish | Baseline duration | Total slack | Constraint | Resources | Work | Actual work | Text1 | Text6 | Text4 | Text5 | Text8 | Text12 |
| --- | --- | --- | --- | --- | --- | --- | --- | --- | --- | --- | --- | --- | --- | --- | --- | --- | --- | --- | --- | --- | --- |
| 31 | 6.3.2 | **CT3 aspects of SAES** | 290d? | 2007-02-05 | 2008-03-14 |  |  | 2007-02-05 | 2008-03-14 | 290d? | 196d |  | C3 | 11600h |  | SAES-St3 | Rel-8 |  |  |  |  |
| 32 | 6.3.2.1 | PCC aspects of SAE | 290d? | 2007-02-05 | 2008-03-14 |  |  | 2007-02-05 | 2008-03-14 | 290d? | 196d | start no earlier than 2007-02-05 | C3 | 2320h |  | SAES-St3-PCC | Rel-8 |  |  |  |  |
| 33 | 6.3.2.2 | Interworking between EPC and external PDNs | 290d? | 2007-02-05 | 2008-03-14 |  |  | 2007-02-05 | 2008-03-14 | 290d? | 196d | start no earlier than 2007-02-05 | C3 | 2320h |  | SAES-St3-intwk | Rel-8 |  |  |  |  |
| 34 | 6.3.2.3 | QoS mechanisms | 290d? | 2007-02-05 | 2008-03-14 |  |  | 2007-02-05 | 2008-03-14 | 290d? | 196d | start no earlier than 2007-02-05 | C3 | 2320h |  | SAES-St3-QoS | Rel-8 |  |  |  |  |
| 35 | 6.3.2.4 | CT3 SAE impact on existing capabilities | 290d? | 2007-02-05 | 2008-03-14 |  |  | 2007-02-05 | 2008-03-14 | 290d? | 196d | start no earlier than 2007-02-05 | C3 | 2320h |  | SAES-St3-CT3imp | Rel-8 |  |  |  |  |
| 36 | 6.3.3 | **CT4 aspects of SAES** | 290d? | 2007-02-05 | 2008-03-14 |  |  | 2007-02-05 | 2007-09-21 | 165d? | 196d |  | C4 | 25520h |  | SAES-St3 | Rel-8 |  |  |  |  |
| 37 | 6.3.3.1 | EPC - HSS interface | 290d? | 2007-02-05 | 2008-03-14 |  |  | 2007-02-05 | 2007-09-21 | 165d? | 196d | finish no earlier than 2008-03-14 | C4 | 2320h |  | SAES-St3-EPC_HSS | Rel-8 |  |  |  |  |
| 38 | 6.3.3.2 | Within EPC | 290d? | 2007-02-05 | 2008-03-14 |  |  | 2007-02-05 | 2007-09-21 | 165d? | 196d | finish no earlier than 2008-03-14 | C4 | 2320h |  | SAES-St3-EPC | Rel-8 |  |  |  |  |
| 39 | 6.3.3.3 | EPC - GPRS | 290d? | 2007-02-05 | 2008-03-14 |  |  | 2007-02-05 | 2007-09-21 | 165d? | 196d | finish no earlier than 2008-03-14 | C4 | 2320h |  | SAES-St3-EPC_GPRS | Rel-8 |  |  |  |  |
| 40 | 6.3.3.4 | EPC - non-3GPP IP access | 290d? | 2007-02-05 | 2008-03-14 |  |  | 2007-02-05 | 2007-09-21 | 165d? | 196d | finish no earlier than 2008-03-14 | C4 | 2320h |  | SAES-St3-EPC_n3G | Rel-8 |  |  |  |  |
| 41 | 6.3.3.5 | AAA/HSS related | 290d? | 2007-02-05 | 2008-03-14 |  |  | 2007-02-05 | 2007-09-21 | 165d? | 196d | finish no earlier than 2008-03-14 | C4 | 2320h |  | SAES-St3-AAA_HSS | Rel-8 |  |  |  |  |
| 42 | 6.3.3.6 | EPC - AAA interface | 290d? | 2007-02-05 | 2008-03-14 |  |  | 2007-02-05 | 2007-09-21 | 165d? | 196d | finish no earlier than 2008-03-14 | C4 | 2320h |  | SAES-St3-EPC_AAA | Rel-8 |  |  |  |  |
| 43 | 6.3.3.7 | EPC - EPC | 290d? | 2007-02-05 | 2008-03-14 |  |  | 2007-02-05 | 2007-09-21 | 165d? | 196d | finish no earlier than 2008-03-14 | C4 | 2320h |  | SAES-St3-EPC_EPC | Rel-8 |  |  |  |  |
| 44 | 6.3.3.8 | SAE / LTE identities | 290d? | 2007-02-05 | 2008-03-14 |  |  | 2007-02-05 | 2007-09-21 | 165d? | 196d | finish no earlier than 2008-03-14 | C4 | 2320h |  | SAES-St3-IDs | Rel-8 |  |  |  |  |
| 45 | 6.3.3.9 | MME - SGSN "signalling free" protocol | 290d? | 2007-02-05 | 2008-03-14 |  |  | 2007-02-05 | 2007-09-21 | 165d? | 196d | finish no earlier than 2008-03-14 | C4 | 2320h |  | SAES-St3-MME_SGSN | Rel-8 |  |  |  |  |
| 46 | 6.3.3.10 | CT4 SAE impact on existing capabilities | 290d? | 2007-02-05 | 2008-03-14 |  |  | 2007-02-05 | 2007-09-21 | 165d? | 196d | finish no earlier than 2008-03-14 | C4 | 2320h |  | SAES-St3-impacts | Rel-8 |  |  |  |  |
| 47 | 6.3.4 | Deleted - UE to EPC NAS signalling (incl. MBMS and QoS aspects) | 290d? | 2007-02-05 | 2008-03-14 |  |  | 2007-02-05 | 2008-03-14 | 290d? | 196d | start no earlier than 2007-02-05 | C1 | 2320h |  | SAES-St3-sig | Rel-8 |  |  |  |  |
| 48 | 6.3.5 | Deleted -User and Control plane protocols | 165d? | 2007-02-05 | 2007-09-21 |  |  | 2007-02-05 | 2007-09-21 | 165d? | 321d | finish no earlier than 2007-09-21 | C4 | 1320h |  | SAES-St3-prot | Rel-8 |  |  |  |  |
| 49 | 6.4 | Deleted - GPRS enhancements for LTE access | 198d? | 2006-12-01 A | 2007-09-04 | 15% | 168.3d? | 2006-12-01 | 2007-09-04 | 198d? | 334d | start no earlier than 2006-12-01 | S2 | 1584h | 237.6h | SAES-GPRS_LTE | Rel-8 | Chris Pudney (Vodafone) | chris.pudney@vodafone.com | Maurice |  |
| 50 | 6.5 | Deleted - Architecture enhancements for non-3GPP accesses | 198d? | 2006-12-01 A | 2007-09-04 | 15% | 168.3d? | 2006-12-01 | 2007-09-04 | 198d? | 334d | start no earlier than 2006-12-01 | S2 | 1584h | 237.6h | SAES-non_3GPP | Rel-8 | Irfan Ali (Motorola) | Irfan.Ali@motorola.com | Maurice |  |
| 51 | 6.6 | Deleted: Stage 2 of architecture for the 3GPP System Architecture Evolution | 290d? | 2007-02-05 A | 2008-03-14 | 4% | 279.7d? | 2006-12-01 | 2007-09-14 | 206d? | 196d |  | S2 | 2320h | 82.4h | SAES-St2 | Rel-8 | Chris Pudney (Vodafone) | chris.pudney@vodafone.com | Maurice | SP-34 |
| 52 | 7 | GERAN support for GERAN - 3G Long Term Evolution interworking | 376d? | 2006-09-08 A | 2008-02-15 | 10% | 338.4d? | 2006-09-08 | 2008-02-15 | 376d? | 216d | finish no earlier than 2008-02-15 | GP | 3008h | 300.8h | GELTE | Rel-8 | Han van Bussel, T-Mobile | han.van.bussel@t-mobile.de | Paolo |  |
| 53 | 8 | **Enhanced USIM Phonebook** | 261d? | 2006-06-22 | 2007-06-21 |  |  | 2006-06-22 | 2007-06-21 | 261d? | 387d |  | C6 | 5224h |  | eUPHBOOK | Rel-8 | Claus Dietze (Giesecke & Devrient) |  |  |  |
| 54 | 8.1 | Requirements for eUPHBOOK | 131d? | 2006-06-22 | 2006-12-21 |  |  | 2006-06-22 | 2006-12-21 | 131d? | 517d | start no earlier than 2006-06-22 | C6 | 1048h |  | eUPHBOOK-St1 | Rel-8 |  |  |  |  |
| 55 | 8.2 | Implementation of eUPHBOOK | 261d? | 2006-06-22 | 2007-06-21 |  |  | 2006-06-22 | 2007-06-21 | 261d? | 387d | finish no earlier than 2007-06-21 | C6 | 2088h |  | eUPHBOOK-St23 | Rel-8 |  |  |  |  |

Notes:
- 33: 08/03/2007 08:00
- 34: 08/03/2007 08:00
- 35: 08/03/2007 08:00
- 49: SP-34: GPRS enhancements for LTE access item created. / Text3: 23.401
- 50: SP-34: Architecture enhancements for non-3GPP accesses item created. / Text3: 23.402
- 51: THIS LINE IS DELETED, replaced by the 2 Architecture parallel tracks. / Text3: 23.002, 23.060, 23.107, 23.203, 23.228, 23.234, 23.246, 23.271, 23.279
- 52: Text3: 24.008, 43.055, 43.129, 43.246, 44.018, 44.060, 45.002, 45.008, 45.010, 48.008,48.018, 51.010
- 53: Moved from Rel-7 to Rel-8 at CT#33
- 54: Text3: 21.111
- 55: Text3: 31.102

| ID | WBS | Task | Duration | Start | Finish | Complete | Remaining | Baseline start | Baseline finish | Baseline duration | Total slack | Constraint | Resources | Work | Actual work | Text1 | Text3 | Text4 | Text5 | Text6 | Text8 | Text7 |
| --- | --- | --- | --- | --- | --- | --- | --- | --- | --- | --- | --- | --- | --- | --- | --- | --- | --- | --- | --- | --- | --- | --- |
| 56 | 9 | **Enhancements for VGCS Applications** | 438d? | 2006-03-15 A | 2007-11-16 | 38% | 270.35d? | 2006-03-15 | 2007-11-16 | 438d? | 281d |  | S1 | 12176h | 3472.08h | EVA | 42.068 | Amar Deol, Nortel Networks | deola@nortel.com | Rel-8 | Michael |  |
| 57 | 9.1 | SA1 aspects for EVA | 191d? | 2006-03-15 A | 2006-12-06 A | 100% |  | 2006-03-15 | 2006-12-06 | 191d? |  | finish no earlier than 2006-12-06 | S1 | 1528h | 1528h | EVA-s1 | 42.068 | Amar Deol, Nortel Networks | deola@nortel.com | Rel-8 | Michael |  |
| 58 | 9.2 | C1 aspects for EVA | 271d? | 2006-06-02 A | 2007-06-15 | 25% | 203.25d? | 2006-06-02 | 2007-06-15 | 271d? | 391d | finish no earlier than 2007-06-15 | C1 | 2168h | 542h | EVA-c1 | 43.068, 44.068 | Milan Patel | milanpa@nortel.com | Rel-8 | Andrijana |  |
| 59 | 9.3 | C4 aspects for EVA | 261d? | 2006-06-02 A | 2007-06-01 | 46% | 140.94d? | 2006-06-02 | 2007-03-09 | 201d? | 401d | finish no earlier than 2007-06-01 | C4 | 2088h | 960.48h | EVA-c4 | 29.002 |  |  | Rel-8 | Kimmo |  |
| 60 | 9.4 | GERAN2 Aspects of EVA | 361d? | 2006-06-30 A | 2007-11-16 | 10% | 324.9d? | 2006-06-30 | 2007-11-16 | 361d? | 281d | finish no earlier than 2007-11-16 | G2 | 2888h | 288.8h | EVA-EVGCSA | 44.018, 48.008 | Frank Billenkamp (Notrtel Networks) | frank.billenkamp@nortel.com | Rel-8 | Gert |  |
| 61 | 10 | **IMS Service Brokering enhancements** | 69d? | 2005-12-07 A | 2006-03-13 A | 100% |  | 2005-12-07 | 2006-03-13 | 69d? |  |  | S1 | 1104h | 1104h | ISB | 22.228 | John-Luc Bakker (Telcordia) | jbakker@telcordia.com | Rel-8 | Michael |  |
| 62 | 10.1 | Stage 1 of ISB | 69d? | 2005-12-07 A | 2006-03-13 A | 100% |  | 2005-12-07 | 2006-03-13 | 69d? |  | finish no earlier than 2006-03-13 | S1 | 552h | 552h | ISB-s1 | 22.228 | John-Luc Bakker (Telcordia) | jbakker@telcordia.com | Rel-8 | Michael |  |
| 63 | 11 | **Multimedia Priority Service** | 337d? | 2006-06-08 A | 2007-09-21 | 46% | 181.75d? | 2006-06-08 | 2007-09-21 | 337d? | 321d |  | S1 | 7072h | 3360h | PRIOR | 22.153 | Jim Garrahan (Telcordia) | jgarraha@telcordia.com | Rel-8 | Michael |  |
| 64 | 11.1 | Service Requirements for PRIOR | 336d? | 2006-06-08 A | 2007-09-20 | 75% | 84d? | 2006-06-08 | 2007-09-20 | 336d? | 322d | finish no earlier than 2007-09-20 | S1 | 2688h | 2016h | PRIOR-EMR | 22.153 | Jim Garrahan (Telcordia) | jgarraha@telcordia.com | Rel-8 | Michael |  |
| 65 | 11.2 | Multimedia Priority Service for PRIOR | 211d? | 2006-12-01 | 2007-09-21 |  |  | 2006-12-01 | 2007-09-21 | 211d? | 321d | finish no earlier than 2007-09-21 | C1 | 1688h |  | PRIOR-MM | 24.229 | Keith Drage, Alcatel-Lucent | drage@Alcatel-Lucent.com | Rel-8 | Andrijana |  |
| 66 | 12 | eCall Data Transfer – Requirements | 51d? | 2006-09-28 A | 2006-12-07 A | 100% |  | 2006-09-28 | 2006-12-07 | 51d? |  | finish no earlier than 2006-12-07 | S1 | 408h | 408h | EData | 22.101, 22.105 | Rhys Robinson (Airbiquity) | rrobinson@airbiquity.com | Rel-8 | Maurice |  |
| 67 | 13 | Local Charging Zone Requirements | 51d? | 2006-09-28 A | 2006-12-07 A | 100% |  | 2006-09-28 | 2006-12-07 | 51d? |  | finish no earlier than 2006-12-07 | S1 | 408h | 408h | LCZR | 22.115 | Hong Liu (China Mobile) | liuhongyfw@chinamobile.com | Rel-8 | Michael |  |
| 68 | 14 | Enhancements to BS30 Bearer service for Videotelephony | 51d? | 2007-01-04 A | 2007-03-15 | 10% | 45.9d? | 2007-01-04 | 2007-03-15 | 51d? | 457d | finish no earlier than 2007-03-15 | S1 | 408h | 40.8h | BS30 | 22.002, 22.004, 22.101, 22.105, 24.008 | Andre Jarvis (3) | andre.jarvis@three.co.uk | Rel-8 | Michael |  |
| 69 | 15 | Deleted (never approved) FBI Phase 2 | 349d? | 2006-06-30 | 2007-10-31 |  |  | 2006-06-30 | 2007-10-31 | 349d? | 293d | start no earlier than 2006-06-30 | S2 | 2792h |  | FBI2 |  |  |  | Rel-8 | Maurice | TSG |
| 70 | 16 | **System enhancements for TISPAN Rel 2** | 349d? | 2006-06-30 A | 2007-10-31 | 9% | 316.76d? | 2006-06-30 | 2007-10-31 | 349d? | 293d |  | S2 | 7208h | 665.96h | FBI2-TISP2 |  |  |  | Rel-8 |  |  |
| 71 | 16.1 | Deleted (never approved) - Stage 2 of FBI for TISPAN R2 - Rel 8 | 349d? | 2006-06-30 | 2007-10-31 |  |  | 2006-06-30 | 2007-10-31 | 349d? | 293d | finish no earlier than 2007-10-31 | S2 | 2792h |  | FBI2-TISP2-s2 |  |  |  | Rel-8 |  |  |
| 72 | 16.2 | Protocol impact of FBI for TISPAN R2 | 152d? | 2006-08-16 | 2007-03-15 |  |  | 2006-08-16 | 2007-03-15 | 152d? | 457d | finish no earlier than 2007-03-15 | C1 | 1216h |  | FBI2-TISP2-c1 |  |  |  | Rel-8 |  |  |
| 73 | 16.3 | Charging harmonization for NGN between 3GPP and ATIS-TMOC | 51d? | 2006-09-28 A | 2006-12-07 A | 100% |  | 2006-09-28 | 2006-12-07 | 51d? |  | finish no earlier than 2006-12-07 | S5 | 408h | 408h | FBI2-TISP2-CH | 32.297 | Amdocs | yishai.brown@amdocs.com | Rel-7 | Adrian |  |
| 74 | 17 | **IMS Enhancements for support of Packet Cable access** | 272d? | 2006-12-06 A | 2007-12-20 | 6% | 255.41d? |  |  |  | 257d |  | S2 | 18288h | 1177.38h | PktCbl |  |  |  | Rel-8 |  |  |
| 75 | 17.1 | **IMS Enhancements for Security Requirements in Support of Cable Deployments** | 272d? | 2006-12-06 | 2007-12-20 |  |  | 2006-12-06 | 2007-12-20 | 272d? | 257d |  | S3 | 7232h |  | PktCbl-Sec | 33.203, 33.210, 33.220, 24.229 | Steve Dotson (Cablelabs) | s.dotson@cablelabs.com | Rel-8 | Michael |  |
| 76 | 17.1.1 | S3 Aspects of PktCbl-Sec | 272d? | 2006-12-06 | 2007-12-20 |  |  | 2006-12-06 | 2007-12-20 | 272d? | 257d | finish no earlier than 2007-12-20 | S3 | 2176h |  | PktCbl-Sec | 33.203, 33.210, 33.220, 24.229 | Steve Dotson (Cablelabs) | s.dotson@cablelabs.com | Rel-8 | Michael |  |
| 77 | 17.1.2 | CT1 Aspects of PktCbl-Sec | 180d? | 2007-03-26 | 2007-11-30 |  |  |  |  |  | 271d | start no earlier than 2007-03-26 | C1 | 1440h |  | PktCbl-Sec | 24.229, 24.109 | David Hancock (CableLabs) | D.Hancock@ CableLabs.com | Rel-8 | Andrijana |  |
| 78 | 17.1.3 | CT4 Aspects of PktCbl-Sec | 180d? | 2007-03-26 | 2007-11-30 |  |  |  |  |  | 271d | start no earlier than 2007-03-26 | C4 | 1440h |  | PktCbl-Sec | 29.228, 29229, 23.008, | David Hancock (CableLabs) | D.Hancock@ CableLabs.com | Rel-8 | Kimmo |  |
| 79 | 17.2 | **IMS Enhancements for Cable Client Types and Deployment Models** | 215d? | 2007-02-05 A | 2007-11-30 | 12% | 189.71d? |  |  |  | 271d |  | S2 | 4440h | 522.35h | PktCbl-Deploy |  |  |  | Rel-8 |  |  |
| 80 | 17.2.1 | Architecture aspects of PktCbl-Deploy | 160d? | 2007-02-05 A | 2007-09-14 | 25% | 120d? |  |  |  | 326d | start no earlier than 2007-02-05 | S2 | 1280h | 320h | PktCbl-Deploy |  |  |  | Rel-8 |  |  |
| 81 | 17.2.2 | CT1 aspects of PktCbl-Deploy | 180d? | 2007-03-26 | 2007-11-30 |  |  |  |  |  | 271d | start no earlier than 2007-03-26 | C1 | 1440h |  | PktCbl-Deploy | 24.229, 24167 | David Hancock (CableLabs) | D.Hancock@ CableLabs.com | Rel-8 | Andrijana |  |

Notes:
- 59: CT4#32: Crs are presented and in principle agreed, waiting for the approval of stage2...
- 63: Created by MCC to group 320023 (Stage 1) and 340012 (Stage 3) wrongly shown as idependent Features
- 64: Official name is "Multimedia Priority Service" but this is identical to UID 31041
- 65: "CT1" corrected into "C1"
- 69: Added by MCC as a consequence of the move to Rel8 of TISPAN Rel-2 impacts on 3GPP
- 71: It might be more appropriate to introduce the individual functions instead of a global title
- 73: 09/2006 SA#33 WID approved
- 77: Supporting Companies:
- 78: Supporting Companies:
- 81: Supporting Companies:

| ID | WBS | Task | Duration | Start | Finish | Complete | Remaining | Baseline start | Baseline finish | Baseline duration | Total slack | Constraint | Resources | Work | Actual work | Text1 | Text4 | Text5 | Text6 | Text8 | Text7 |
| --- | --- | --- | --- | --- | --- | --- | --- | --- | --- | --- | --- | --- | --- | --- | --- | --- | --- | --- | --- | --- | --- |
| 82 | 17.3 | **IMS Inter-working Aspects in Support of Cable Regulatory requirements** | 215d? | 2007-02-05 A | 2007-11-30 | 12% | 189.71d? |  |  |  | 271d |  | S2 | 4440h | 522.35h | PktCbl-Intw | Bernie McKibben (CableLabs) | B.McKibben@CableLabs.com | Rel-8 | Maurice |  |
| 83 | 17.3.1 | Architecture aspects of PktCbl-Interwork | 160d? | 2007-02-05 A | 2007-09-14 | 25% | 120d? |  |  |  | 326d | start no earlier than 2007-02-05 | S2 | 1280h | 320h | PktCbl-Intw | Bernie McKibben (CableLabs) | B.McKibben@CableLabs.com | Rel-8 | Maurice |  |
| 84 | 17.3.2 | CT1 aspects of PktCbl-Deploy | 180d? | 2007-03-26 | 2007-11-30 |  |  |  |  |  | 271d | start no earlier than 2007-03-26 | C1 | 1440h |  | PktCbl-Intw | David Hancock (CableLabs) | D.Hancock@ CableLabs.com | Rel-8 | Andrijana |  |
| 85 | 18 | Services Alignment and Migration | 256d? | 2006-12-06 A | 2007-11-28 | 65% | 89.6d? | 2006-09-28 | 2007-09-20 | 256d? | 273d | finish no earlier than 2007-09-20 | S1 | 2048h | 1331.2h | CusAlert | Feng Lingjuan (China Mobile) | (fenglingjuan@chinamobile.com) | Rel-8 | Michael |  |
| 86 | 19 | Support of Customised Alerting Tone Service | 207d? | 2006-12-06 A | 2007-09-20 | 65% | 72.45d? | 2006-12-06 | 2007-09-20 | 207d? | 322d | finish no earlier than 2007-09-20 | S1 | 1656h | 1076.4h | CusAlert | Feng Lingjuan (China Mobile) | (fenglingjuan@chinamobile.com) | Rel-8 | Michael |  |
| 87 | 20 | I-WLAN NSP | 6d? | 2006-12-06 A | 2006-12-13 | 50% | 3d? | 2006-12-06 | 2006-12-13 | 6d? | 523d | finish no earlier than 2006-12-13 | S1 | 48h | 24h | IWLANNSP | Chris Friel (O2) | chris.friel@o2.com | Rel-8 | Michael |  |
| 88 | 21 | Support of Service-Level Interworking for Messaging Services | 132d? | 2006-12-06 A | 2007-06-07 A | 100% |  | 2006-12-06 | 2007-06-07 | 132d? |  | finish no earlier than 2007-06-07 | S1 | 1056h | 1056h | MESSIW | Liu Ling (Huawei) | ling.liu@huawei.com | Rel-8 | Michael |  |
| 89 | 22 | Delete - was a Rel7 item - LCS for 3GPP Interworking WLAN | 245d? | 2006-10-23 | 2007-09-28 |  |  | 2006-10-23 | 2007-09-28 | 245d? | 316d | finish no earlier than 2007-09-28 | S2 | 1960h |  | LCS4_IWLAN | Donghee Shim (LG Electronics Inc.) | dhshim@lge.com | Rel-8 | Maurice |  |
| 90 | 23 | **OAM&P 8 (not yet official)** | 857d? | 2005-09-02 A | 2008-12-15 | 64% | 312.77d? |  |  |  | 0d |  | S5 | 39768.2h | 15363.6h | OAM8 |  |  | Rel-8 | Adrian |  |
| 91 | 23.1 | **Network Infrstructure Management 8** | 857d? | 2005-09-02 A | 2008-12-15 | 78% | 190.87d? |  |  |  | 0d |  | S5 | 20830h | 12741.2h | OAM8-NIM |  |  | Rel-8 | Adrian |  |
| 92 | 23.1.1 | Integration Reference Point (IRP) Methodology | 857d? | 2005-09-02 A | 2008-12-15 | 85% | 128.55d? | 2005-09-02 | 2008-12-15 | 857d? | 0d | finish no earlier than 2008-12-15 | S5 | 6856h | 5827.6h | OAM8-NIM | Ericsson |  | Rel-8 | Adrian |  |
| 93 | 23.1.2 | Advanced Alarming on Itf-N (Study + Implementation) | 596d? | 2005-09-02 A | 2007-12-14 | 65% | 208.6d? | 2005-09-02 | 2007-06-14 | 465d? | 261d | finish no earlier than 2007-12-14 | S5 | 4768h | 3099.2h | OAM8-NIM | Siemens |  | Rel-8 | Adrian |  |
| 94 | 23.1.3 | CN CS Bearer Transport Network (BTN) relative NRM | 596d? | 2005-09-02 A | 2007-12-14 | 80% | 119.2d? | 2005-09-02 | 2007-03-15 | 400d? | 261d | finish no earlier than 2007-12-14 | S5 | 4768h | 3814.4h | OAM8-NIM | China Mobile |  | Rel-8 | Adrian |  |
| 95 | 23.2 | **Performance Management 8** | 596d? | 2005-09-02 A | 2007-12-14 | 55% | 268.2d? |  |  |  | 261d |  | S5 | 7776h | 2622.4h |  |  |  | Rel-8 | Adrian |  |
| 96 | 23.2.1 | IP bearer network Performance measurement definitions | 596d? | 2005-09-02 A | 2007-12-14 | 55% | 268.2d? | 2005-09-02 | 2007-03-15 | 400d? | 261d | finish no earlier than 2007-12-14 | S5 | 4768h | 2622.4h | OAM7-PM | China Mobile |  | Rel-8 | Adrian |  |
| 97 | 23.3 | **Trace Management 8** | 404.96d? | 2006-09-22 A | 2008-04-10 |  | 404.96d? |  |  |  | 177.04d |  | S5 | 6066.23h |  |  |  |  | Rel-8 |  |  |
| 98 | 23.3.1 | Service Level Tracing in IMS | 379.14d? | 2006-09-22 A | 2008-04-10 |  | 379.14d? | 2006-09-22 | 2007-06-08 | 179.14d? | 177.04d | finish no earlier than 2008-03-15 | C1 | 3033.12h |  | OAM7-Trace | Jari Jansson, Nokia | jari.jansson@nokia.com | Rel-8 | Andrijana |  |
| 99 | 24 | Registration in Densely-populated area | 4d? | 2007-03-12 A | 2007-03-15 | 90% | 0.4d? |  |  |  | 457d | start no earlier than 2007-03-12 | S1 | 32h | 28.8h | RED | Tsuyoshi Takakura (NTT DoCoMo Inc.) | takakurat@s1.nttdocomo.co.jp | Rel-8 | Michael |  |
| 100 | 25 | Lawful Interception in the 3GPP Rel-8 | 4d? | 2007-03-12 | 2007-03-15 |  |  |  |  |  | 457d | start no earlier than 2007-03-12 | S3 | 32h |  |  | Berthold Wilhelm (BMWi/BNetzA) | berthold.wilhelm@bnetza.de | Rel-8 | Michael |  |
| 101 | 26 | **Rel-8 Improvements of the Radio Interface** | 215d? | 2007-03-05 A | 2007-12-28 |  | 215d? | 2004-09-15 | 2007-06-15 | 718d? | 251d |  | RP | 7840h | 808h | RInImp8 |  |  | Rel-8 | Claude |  |
| 102 | 26.1 | UMTS 1500 MHz | 140d? | 2007-03-05 | 2007-09-14 |  |  | 2004-09-15 | 2005-06-14 | 195d? | 326d | finish no earlier than 2007-09-14 | R4 | 1120h |  | RInImp8-UMTS1500 | Takehiro Nakamura | NTT DoCoMo | Rel-8 | Claude | TSG |
| 103 | 26.2 | UMTS 700 MHz | 215d? | 2007-03-05 | 2007-12-28 |  |  | 2004-09-15 | 2005-06-14 | 195d? | 251d | start no earlier than 2007-03-05 | R4 | 1720h |  | RInImp8-UMTS700 | Tuomo Saynajakangas | Nokia | Rel-8 | Claude | TSG |
| 104 | 26.3 | UMTS 2300 MHz | 215d? | 2007-03-05 | 2007-12-28 |  |  | 2004-09-15 | 2005-06-14 | 195d? | 251d | start no earlier than 2007-03-05 | R4 | 1720h |  | RInImp8-UMTS2300 | Marc Grant | marc.grant@cingular.com | Rel-8 | Claude | TSG |
| 105 | 26.4 | Further Improved Performance Requirements for UMTS/HSDPA UE (FDD) | 215d? | 2007-03-05 | 2007-12-28 |  |  | 2005-12-15 | 2007-03-15 | 326d? | 251d | finish no earlier than 2007-12-28 | R4 | 1720h |  | RInImp8-2BIC | Marc Grant, Cingular | marc.grant@cingular.com | Rel-8 | MCC_RAN |  |

Notes:
- 82: Supporting Companies: CableLabs, Nortel, Cisco, Samsung, Alcatel-Lucent, Siemens, Motorola, Hewlett-Packard, Ericsson / Text3: 23.228
- 83: Supporting Companies: CableLabs, Nortel, Cisco, Samsung, Alcatel-Lucent, Siemens, Motorola, Hewlett-Packard, Ericsson / Text3: 23.228
- 84: Supporting Companies: / Text3: 24.229
- 85: previous names were Services Alignment, Service Migration / Text3: 22.182
- 86: Text3: 22.182
- 87: Text3: 22.234
- 88: Text3: 22.105, 22.340
- 89: New WID approved SP-34. Supporting companies: Telcordia, Samsung, Qualcomm, BT, LG Electronics, Cingular, Alcatel-Lucent. No scheduled end date! / Text3: 23.234, 23.271, 23.167
- 90: Created to encompass the Rel7 Work Tasks shifted to Rel8
- 91: Created to encompass the Rel7 Work Tasks shifted to Rel8
- 92: Request to TSG#35 to move to Release 8 / Text3: new TSs 32.153,32.154,32.15y,32.15z; CRs to 32.150,32.151,32.152
- 93: Request to TSG#35 to move to Release 8 / Text3: TR 32.8xy
- 94: Request to TSG#35 to move to Release 8 / Text3: 32.74x
- 95: Created to encompass the Rel7 Work Tasks shifted to Rel8
- 96: Request to TSG#35 to move to Release 8 / Text3: 32.404,32.405,32.406,32.407
- 97: Created to encompass the Rel7 Work Tasks shifted to Rel8
- 98: Request to TSG#35 to move to Release 8 / Text3: 24.229, 24.167, 29.228,29.229,29.163,29.332
- 99: One CR at SA #35 / Text3: 22.101
- 100: End date to be determined when Rel-8 frozen. / Text3: 33.106, 33.107, 33.108
- 102: Text3: TS25.101, TS25.104, TS25.133, TS25.141, TS25.331, TS25.942, TS25.306, TS25.307, TS34.121
- 103: Text3: TS25.101, TS25.104, TS25.133, TS25.141, TS25.331, TS25.942, TS25.306, TS25.307, TS34.121
- 104: Text3: TS25.101, TS25.104, TS25.133, TS25.141, TS25.331, TS25.942, TS25.306, TS25.307, TS34.121

| ID | WBS | Task | Duration | Start | Finish | Complete | Remaining | Baseline start | Baseline finish | Baseline duration | Total slack | Constraint | Resources | Work | Actual work | Text1 | Text4 | Text5 | Text6 | Text8 | Text3 | Text12 | Text7 |
| --- | --- | --- | --- | --- | --- | --- | --- | --- | --- | --- | --- | --- | --- | --- | --- | --- | --- | --- | --- | --- | --- | --- | --- |
| 106 | 27 | **Personal Network Management** | 708d? | 2005-07-11 A | 2008-03-26 | 29% | 500.9d? | 2005-07-11 | 2007-10-30 | 601.6d? | 188d |  | S1 | 12017.6h | 3515.37h | PNM | Armin Toepfer, Vodafone | armin.toepfer@vodafone.com | Rel-8 | Mike |  |  |  |
| 107 | 27.1 | Stage 1 of PNPAM | 276d? | 2005-07-11 A | 2006-07-31 | 85% | 41.4d? | 2005-07-11 | 2006-07-31 | 276d? | 620d | start no earlier than 2005-07-11 | S1 | 2208h | 1876.8h | PNM |  |  | Rel-8 |  | 22.259, 23.818 |  |  |
| 108 | 27.2 | CT1 aspects of PNM | 263d? | 2007-03-26 | 2008-03-26 |  |  |  |  |  | 188d | start no earlier than 2007-03-26 | C1 | 2104h |  | PNM | Yang Lu, |  | Rel-8 |  | New TS 23.xyz, 24.229 |  |  |
| 109 | 27.3 | CT4 aspects of PNM | 263d? | 2007-03-26 | 2008-03-26 |  |  |  |  |  | 188d | start no earlier than 2007-03-26 | C4 | 2104h |  | PNM | Yang Lu, |  | Rel-8 |  | 23.008, 23.018, 29.002, 29.328, 29.329 |  |  |
| 110 | 28 | (Small) Technical Enhancements and Improvements for Rel-8 | 400d? | 2007-01-01 | 2008-07-11 |  |  | 2007-01-01 | 2008-07-11 | 400d? | 111d | start no earlier than 2007-01-01 | All | 3200h |  | TEI8 |  |  | Rel-8 |  |  |  |  |
| 111 | 29 | **Charging Management small Enhancements** | 420d? | 2006-05-08 | 2007-12-14 |  |  | 2006-05-22 | 2007-03-15 | 214d? | 261d |  | S5 | 6640h |  | CH8 | Orange |  | Rel-8 | Adrian | 32.2xy |  |  |
| 112 | 29.1 | Online charging correlation | 420d? | 2006-05-08 | 2007-12-14 |  |  | 2006-05-22 | 2007-03-15 | 214d? | 261d | finish no earlier than 2007-12-14 | S5 | 3360h |  |  | Orange | alain.bibas@orange-ft.com | Rel-8 |  | 32.240, 32.296 |  |  |
| 113 | 30 | Rel-8 Feasibility Studies | 1d? | 2000-01-03 | 2000-01-03 |  |  | 2000-01-03 | 2000-01-03 | 1d? | 2335d |  | CT;RAN;SA | 8h |  |  |  |  | Rel-8 |  |  |  |  |
| 114 | 31 | Study on Facilitating Machine to Machine Communication in GSM and UMTS (M2M) | 161d? | 2005-11-04 A | 2006-06-16 | 90% | 16.1d? | 2005-11-04 | 2006-06-16 | 161d? | 651d | finish no earlier than 2006-06-16 | S1 | 1288h | 1159.2h | M2M | Juergen Merkel, Siemens AG |  | Rel-8 | Michael | 22.868 |  |  |
| 115 | 32 | FS on Network Composition | 211d? | 2005-12-07 A | 2006-09-27 | 90% | 21.1d? | 2005-12-07 | 2006-09-27 | 211d? | 578d | finish no earlier than 2006-09-27 | S1 | 1688h | 1519.2h | NetComp | Joerg Swetina (Siemens) | joerg.swetina@siemens.com | Rel-8 |  | 22.980 |  |  |
| 116 | 33 | Study on Charging Aspects of 3GPP System Evolution | 120d? | 2007-04-02 | 2007-09-14 |  |  | 2006-05-10 | 2008-12-15 | 679d? | 326d | start no earlier than 2007-04-02 | S5 | 960h |  |  | Siemens | gerald.goermer@siemens.com | Rel-8 |  | new TR 32.8xy | SP-32 |  |
| 117 | 34 | **All-IP Network (AIPN)** | 448d? | 2004-06-28 A | 2006-03-15 A | 100% |  | 2004-06-28 | 2006-03-15 | 448d? |  |  | S1 | 8672h | 8672h | AIPN | Chris Sachno (NTT DoCoMo) | c.masyu@nttdocomo.co.jp | Rel-8 | Michael | 22.978 |  | TSG |
| 118 | 34.1 | All-IP Network Feasibility Study | 188d? | 2004-06-28 A | 2005-03-16 A | 100% |  | 2004-06-28 | 2005-03-16 | 188d? |  | start no earlier than 2004-06-28 | S1 | 1504h | 1504h | AIPFS | Chris Sachno (NTT DoCoMo) | c.masyu@nttdocomo.co.jp | Rel-8 | Michael | 22.978 |  | TSG |
| 119 | 34.2 | Stage1 | 448d? | 2004-06-28 A | 2006-03-15 A | 100% |  | 2004-06-28 | 2006-03-15 | 448d? |  | finish no earlier than 2006-03-15 | S1 | 3584h | 3584h | AIPN | Chris Sachno (NTT DoCoMo) | c.masyu@nttdocomo.co.jp | Rel-8 | Michael | 22.258 |  | TSG |
| 120 | 35 | Study on Stage 2 aspects of IMS Service Brokering | 401d? | 2006-06-19 A | 2007-12-31 | 41% | 236.59d? | 2006-06-19 | 2007-06-22 | 265d? | 250d | finish no earlier than 2007-12-31 | S2 | 3208h | 1315.28h | ISB_ST2_SDY | Raquel Morera (Telcordia); F. Joe Lin (Telcordia) | raquel@research.telcordia.com | Rel-8 | Maurice | 23.810 |  |  |
| 121 | 36 | Study of Requirements of IMS Multimedia Conferencing | 205d? | 2006-06-08 A | 2007-03-21 | 30% | 143.5d? | 2006-06-08 | 2007-03-21 | 205d? | 453d | finish no earlier than 2007-03-21 | S1 | 1640h | 492h | SI-IMSconf | Zheng Jianping (China Mobile ) | zhengjianping@chinamobile.com | Rel-8 | Michael | 22.948 |  |  |
| 122 | 37 | Study on support of a Public Warning System | 205d? | 2006-06-08 A | 2007-03-21 | 55% | 92.25d? | 2006-06-08 | 2007-03-21 | 205d? | 453d | start no earlier than 2006-06-08 | S1 | 1640h | 902h | PWS-SI | Mark Young (T-mobile) | mark.younge@t-mobile.com | Rel-8 | Michael | 22.968 |  |  |
| 123 | 38 | Study on Protection against SMS and MMS spam | 205d? | 2006-06-08 | 2007-03-21 |  |  | 2006-06-08 | 2007-03-21 | 205d? | 453d | start no earlier than 2006-06-08 | S3 | 1640h |  | CPSMal | Eric Gauthier (Orange SA) | eric.gauthier@orange.ch | Rel-8 | Michael | 33.9xx |  |  |
| 124 | 39 | Study of VCC support for Emergency Calls | 408d? | 2006-06-08 A | 2007-12-31 | 36% | 261.12d? | 2006-06-08 | 2007-03-23 | 207d? | 250d | finish no earlier than 2007-12-31 | S2 | 3264h | 1175.04h | FSVCCEm | Bob Beeson, Alcatel-Lucent |  | Rel-8 | Maurice | 23.826 |  |  |
| 125 | 40 | Study on Centralised IMS Service Control | 311d? | 2006-10-23 A | 2007-12-31 | 37% | 195.93d? | 2006-10-23 | 2007-09-14 | 235d? | 250d | finish no earlier than 2007-12-31 | S2 | 2488h | 920.56h | IMS_CSC | Andy Bennett (Alcatel-Lucent) | andybennett@Alcatel-Lucent.com | Rel-8 | Maurice | 23.9de |  |  |
| 126 | 41 | Study on IMS utilizing multicast bearer services | 398d? | 2006-03-22 A | 2007-09-28 | 60% | 159.2d? | 2006-03-22 | 2007-03-02 | 248d? | 316d | finish no earlier than 2007-09-28 | S2 | 3184h | 1910.4h | FS-MLTICAST-IMS | Fiona Zhu (Siemens AG) |  | Rel-8 | Maurice | 23.847 |  |  |
| 127 | 42 | Study on Paging Permission with Access Control | 256d? | 2006-09-28 A | 2007-09-20 | 60% | 102.4d? | 2006-09-28 | 2007-09-20 | 256d? | 322d | finish no earlier than 2007-09-20 | S1 | 2048h | 1228.8h | PPAC | Katsuhiro Noguchi (NTT DoCoMo Inc.) | noguchi@nttdocomo.co.jp | Rel-8 | Michael | 22.908 |  |  |
| 128 | 43 | Study on Non 3GPP access NSP | 207d? | 2006-12-06 A | 2007-09-20 | 15% | 175.95d? | 2006-12-06 | 2007-09-20 | 207d? | 322d | start no earlier than 2006-12-06 | S1 | 1656h | 248.4h | N3GtoNSP | Chris Friel (O2) | chris.friel@o2.com | Rel-8 | Michael | 22.812 |  |  |
| 129 | 44 | Study on Value Added Services for Short Message Service | 263d? | 2006-12-06 A | 2007-12-07 | 10% | 236.7d? | 2006-12-06 | 2007-12-07 | 263d? | 266d | finish no earlier than 2007-12-07 | S1 | 2104h | 210.4h | VAS4SMS | Wu Bin (China Mobile Communications Corporation) | wubin@chinamobile.com | Rel-8 | Michael | 22.xxx |  |  |
| 130 | 45 | Study on Requirements for seamless roaming and service continuity between mobile and WLAN networks | 132d? | 2006-12-06 A | 2007-06-07 | 10% | 118.8d? | 2006-12-06 | 2007-06-07 | 132d? | 397d | finish no earlier than 2007-06-07 | S1 | 1056h | 105.6h | SMLSWLAN | Mike Meyerstein (BT) | mike.meyerstein@bt.com | Rel-8 | Michael | 22.937 |  |  |
| 131 | 46 | Feasibility Study of Mobility between 3GPP-WLAN Interworking and 3GPP Systems | 129d? | 2007-03-20 A | 2007-09-14 | 7% | 119.97d? |  |  |  | 326d | start no earlier than 2007-03-20 | S2 | 1032h | 72.24h | SM3GWLAN | Orange | orange | Rel-8 | Maurice | 23.837 |  |  |

Notes:
- 106: Moved from FS section Feb 06. SP-33: Create new section to capture the PNM stage 2 aspects and identify any impacts to existing stage 2 specifications. S2 added as secondary responsibility
- 107: Moved from FS section Feb 06: SP-33: Create new section to capture the PNM stage 2 aspects and identify any impacts to existing stage 2 specifications.
- 112: WID approved SA#35
- 116: WID approved SA#35
- 120: Study approved SA#32
- 123: Formerly called "Consumer protection against spam and malware"
- 125: Approved at SP#33
- 131: Rapporteur name to be provided. Supporting companies: T-Mobile, Orange, China Mobile, Telenor, Alcatel-Lucent, Azaire Networks, Airvana

| ID | WBS | Task | Duration | Start | Finish | Complete | Remaining | Baseline start | Baseline finish | Baseline duration | Total slack | Constraint | Resources | Work | Actual work | Text6 | Text8 | Text3 | Text4 | Text12 | Text1 | Text5 |
| --- | --- | --- | --- | --- | --- | --- | --- | --- | --- | --- | --- | --- | --- | --- | --- | --- | --- | --- | --- | --- | --- | --- |
| 132 | 47 | **OAM&P Rel-8 Studies (not yet official)** | 596d? | 2005-09-02 A | 2007-12-14 | 49% | 303.11d? |  |  |  | 261d |  | S5 | 13457.6h | 5504h | Rel-8 | Adrian |  |  |  |  |  |
| 133 | 47.1 | Study of Element Operations Systems Function (EOSF) definition | 596d? | 2005-09-02 A | 2007-12-14 | 65% | 208.6d? | 2005-09-02 | 2008-12-15 | 857d? | 261d | finish no earlier than 2007-12-14 | S5 | 4768h | 3099.2h | Rel-8 |  | new TR 32.8xy | China Mobile | SP-32 |  |  |
| 134 | 47.2 | Study on SA5 MTOSI XML Harmonization | 418d? | 2006-05-10 A | 2007-12-14 | 20% | 334.4d? | 2006-05-10 | 2008-12-15 | 679d? | 261d | finish no earlier than 2007-12-14 | S5 | 3344h | 668.8h | Rel-8 |  | new TR 32.8xy | Nortel | SP-32 |  |  |
| 135 | 47.3 | Study of Common Profile Storage (CPS) Framework of User Data for network services and management | 184d? | 2006-07-03 A | 2007-03-15 | 85% | 27.6d? | 2006-07-03 | 2007-03-15 | 184d? | 457d | finish no earlier than 2007-03-15 | S5 | 1472h | 1251.2h | Rel-7 |  | TR 32.808 | T-Mobile |  |  |  |
| 136 | 47.4 | Study of Management for LTE and SAE | 202d? | 2006-12-07 A | 2007-09-14 | 30% | 141.4d? | 2006-12-07 | 2007-06-14 | 136d? | 326d | finish no earlier than 2007-09-14 | S5 | 1616h | 484.8h | Rel-8 |  | TR 32.816 | Ericsson |  |  |  |
| 137 | 48 | SI on AS-MRFC media server control protocol | 318d? | 2006-03-22 A | 2007-06-08 | 60% | 127.2d? | 2006-03-22 | 2007-06-08 | 318d? | 396d | finish no earlier than 2007-06-08 | C1 | 2544h | 1526.4h | Rel-8 |  | New TR 24.880 | Mark Syrett (Hewlett-Packard) |  | MRFC |  |
| 138 | 49 | FS Restoration Procedures | 180d? | 2007-03-26 | 2007-11-30 |  |  |  |  |  | 271d | start no earlier than 2007-03-26 | C4 | 1440h |  | Rel-8 | Kimmo | New TR 23.xyz | German Blanco (Ericsson) |  | FSIMS8_RP | german.blanco@ericsson.com |
| 139 | 50 | FS on 3G Home NodeB | 210d? | 2007-03-05 | 2007-12-21 |  |  |  |  |  | 256d | finish no earlier than 2007-12-21 | R4 | 1680h |  | Rel-8 | Claude |  | Howard Thomas (Motorola) |  | FSHNB |  |

Notes:
- 132: Created to encompass the Rel7 Work Tasks shifted to Rel8
- 133: Request to TSG#35 to move to Release 8
- 134: Request to TSG#35 to move to Release 8
- 135: Submit Exception Sheet for TSG#35 Approval
- 136: 12/2006 SA#34 WID approved
